# Start

Schedule from MS Project, 2008-04-04 to 2008-06-25, costs in Kč.
Encián

## Calendars

- Standardní 2: Mon-Fri 08:00-12:00, 13:00-17:00; Sat-Sun off. Exceptions (off unless hours are given): 2007-01-01 to 2049-12-31 (Nový rok, recurring), 2007-01-01 to 2049-12-31 (Svátek práce, recurring), 2007-01-01 to 2049-12-31 (Den vítězství, recurring), 2007-01-01 to 2049-12-31 (Den slovanských věrozvěstů Cyrila a Metoděje, recurring), 2007-01-01 to 2049-12-31 (Den upálení mistra Jana Husa, recurring), 2007-01-01 to 2049-12-31 (Den české státnosti, recurring), 2007-01-01 to 2049-12-31 (Den vzniku samostatného československého státu, recurring), 2007-01-01 to 2049-12-31 (Den boje za svobodu a demokracii, recurring), 2007-01-01 to 2049-12-31 (Štědrý den, recurring), 2007-01-01 to 2049-12-31 (1. svátek vánoční, recurring), 2007-01-01 to 2049-12-31 (2. svátek vánoční, recurring), 2008-01-01 to 2008-12-31 (Velikonoční pondělí 2008, recurring).
- Koncepce: Mon-Fri 08:00-12:00, 13:00-19:00; Sat-Sun off. Exceptions (off unless hours are given): 2007-01-01 to 2049-12-31 (Nový rok, recurring), 2007-01-01 to 2049-12-31 (Svátek práce, recurring), 2007-01-01 to 2049-12-31 (Den vítězství, recurring), 2007-01-01 to 2049-12-31 (Den slovanských věrozvěstů Cyrila a Metoděje, recurring), 2007-01-01 to 2049-12-31 (Den upálení mistra Jana Husa, recurring), 2007-01-01 to 2049-12-31 (Den české státnosti, recurring), 2007-01-01 to 2049-12-31 (Den vzniku samostatného československého státu, recurring), 2007-01-01 to 2049-12-31 (Den boje za svobodu a demokracii, recurring), 2007-01-01 to 2049-12-31 (Štědrý den, recurring), 2007-01-01 to 2049-12-31 (1. svátek vánoční, recurring), 2007-01-01 to 2049-12-31 (2. svátek vánoční, recurring), 2008-01-01 to 2008-12-31 (Velikonoční pondělí 2008, recurring).

## Resources

| Resource | Rate |
| --- | --- |
| Kolínská | 200 |
| údržbář 1 | 200 |

## Schedule

| ID | Task | Type | Duration | Start | Finish | Predecessors | Total slack | Free slack | Constraint | Calendar | Resources | Work | Cost |
| --- | --- | --- | --- | --- | --- | --- | --- | --- | --- | --- | --- | --- | --- |
| 1 | koncepce vybavení místnosti |  | 1w | 2008-04-04 | 2008-04-09 |  | 0d |  |  | Koncepce | Kolínská; údržbář 1 | 80h | 16,000 |
| 2 | rozpočet vybavení místnosti |  | 2d | 2008-04-08 | 2008-04-09 | 1SS+2d | 0d |  |  |  |  |  |  |
| 3 | schválení koncepce a rozpočtu vybavení |  | 1d | 2008-04-10 | 2008-04-10 | 1, 2 | 0d |  |  |  |  |  |  |
| 4 | výběr a objednání počítačů |  | 3d | 2008-04-11 | 2008-04-15 | 3 | 10d | 0d |  |  |  |  |  |
| 5 | dodání počítačů a dataprojektoru |  | 1d | 2008-04-30 | 2008-04-30 | 4FS+2w | 10d | 9d |  |  |  |  |  |
| 6 | zazdění dveří |  | 2d | 2008-04-11 | 2008-04-14 | 3 | 11d | 0d |  |  |  |  |  |
| 7 | podhled |  | 2d | 2008-04-15 | 2008-04-16 | 6 | 11d | 0d |  |  |  |  |  |
| 8 | elektroinstalace |  | 1d | 2008-04-17 | 2008-04-17 | 7 | 11d | 0d |  |  |  |  |  |
| 9 | vymalování |  | 1d | 2008-04-18 | 2008-04-18 | 8 | 11d | 0d |  |  |  |  |  |
| 10 | položení koberce |  | 1d | 2008-04-21 | 2008-04-21 | 9 | 11d |  |  |  |  |  |  |
| 11 | výběr a objednání nábytku |  | 3d | 2008-04-11 | 2008-04-15 | 3 | 0d |  |  |  |  |  |  |
| 12 | dodání a montáž nábytku |  | 1d | 2008-05-09 | 2008-05-09 | 10, 11FS+3w | 0d |  |  |  |  |  |  |
| 13 | vyvětrání |  | 5ed | 2008-05-09 | 2008-05-14 | 12 | 4.88d | 1.88d |  |  |  |  |  |
| 14 | instalace sítě |  | 1d | 2008-05-15 | 2008-05-15 | 13 | 1d | 0d |  |  |  |  |  |
| 15 | instalace počítačů |  | 1d | 2008-05-16 | 2008-05-16 | 14, 5 | 1d | 0d |  |  |  |  |  |
| 16 | příprava rezervačního software |  | 5d | 2008-04-04 | 2008-04-10 |  | 25d | 24d |  |  |  |  |  |
| 17 | zahájení provozu místnosti | milestone | 0d | 2008-05-16 | 2008-05-16 | 16, 15 | 1d | 0d |  |  |  |  |  |
| 18 | webová prezentace uvedení |  | 2d | 2008-05-19 | 2008-05-20 | 17 | 1d |  |  |  |  |  |  |
| 19 | přihlašování na uvedení |  | 15ed | 2008-06-03 | 2008-06-18 | 18FS+2w | 4.88d | 0d |  |  |  |  |  |
| 20 | objednání občerstvení |  | 1d | 2008-04-11 | 2008-04-11 | 3 | 39d |  |  |  |  |  |  |
| 21 | návrh letáků k uvedení |  | 2d | 2008-04-11 | 2008-04-14 | 3 | 40d | 0d |  |  |  |  |  |
| 22 | dodání letáků | milestone | 0d | 2008-04-14 | 2008-04-14 | 21 | 40d | 0d |  |  |  |  |  |
| 23 | rozeslání pozvánek |  | 2d | 2008-04-15 | 2008-04-16 | 22 | 47d |  |  |  |  |  |  |
| 24 | výběr, objednání propagačních materiálů |  | 1d | 2008-04-11 | 2008-04-11 | 3 | 39d | 0d |  |  |  |  |  |
| 25 | dodání propagačních materiálů | milestone | 0d | 2008-04-11 | 2008-04-11 | 24 | 39d | 0d |  |  |  |  |  |
| 26 | milník přípravy akce uvedení | milestone | 0d | 2008-04-18 | 2008-04-18 | 25FS+5d, 22FS+3d | 39d |  |  |  |  |  |  |
| 27 | uzávěrka přihlašování | milestone | 0d | 2008-06-18 | 2008-06-18 | 19 | 1d |  |  |  |  |  |  |
| 28 | průběh akce uvedení software |  | 1d | 2008-06-24 | 2008-06-24 | 26FS+1w, 20FS+10d, 27FS+2d | 0d |  | must start on 2008-06-24 |  |  |  |  |
| 29 | tisková zpráva o uvedení |  | 1d | 2008-06-25 | 2008-06-25 | 28, 23 | 0d |  |  |  |  |  |  |
