# Start

Schedule from MS Project, 2008-04-04 to 2008-06-25, costs in Kč.
Encián

## Calendars

- Standardní 2: Mon-Fri 08:00-12:00, 13:00-17:00; Sat-Sun off. Exceptions (off unless hours are given): 2007-01-01 to 2049-12-31 (Nový rok, recurring), 2007-01-01 to 2049-12-31 (Svátek práce, recurring), 2007-01-01 to 2049-12-31 (Den vítězství, recurring), 2007-01-01 to 2049-12-31 (Den slovanských věrozvěstů Cyrila a Metoděje, recurring), 2007-01-01 to 2049-12-31 (Den upálení mistra Jana Husa, recurring), 2007-01-01 to 2049-12-31 (Den české státnosti, recurring), 2007-01-01 to 2049-12-31 (Den vzniku samostatného československého státu, recurring), 2007-01-01 to 2049-12-31 (Den boje za svobodu a demokracii, recurring), 2007-01-01 to 2049-12-31 (Štědrý den, recurring), 2007-01-01 to 2049-12-31 (1. svátek vánoční, recurring), 2007-01-01 to 2049-12-31 (2. svátek vánoční, recurring), 2008-01-01 to 2008-12-31 (Velikonoční pondělí 2008, recurring).
- Rodiče: Mon-Fri 08:00-12:00, 13:00-17:00; Sat-Sun off. Exceptions (off unless hours are given): 2007-01-01 to 2049-12-31 (Nový rok, recurring), 2007-01-01 to 2049-12-31 (Svátek práce, recurring), 2007-01-01 to 2049-12-31 (Den vítězství, recurring), 2007-01-01 to 2049-12-31 (Den slovanských věrozvěstů Cyrila a Metoděje, recurring), 2007-01-01 to 2049-12-31 (Den upálení mistra Jana Husa, recurring), 2007-01-01 to 2049-12-31 (Den české státnosti, recurring), 2007-01-01 to 2049-12-31 (Den vzniku samostatného československého státu, recurring), 2007-01-01 to 2049-12-31 (Den boje za svobodu a demokracii, recurring), 2007-01-01 to 2049-12-31 (Štědrý den, recurring), 2007-01-01 to 2049-12-31 (1. svátek vánoční, recurring), 2007-01-01 to 2049-12-31 (2. svátek vánoční, recurring), 2008-01-01 to 2008-12-31 (Velikonoční pondělí 2008, recurring), 2008-05-17 08:00-12:00, 13:00-17:00 (Pracovní sobota), 2008-05-19 (Volné pondělí).
- Koncepce: Mon-Fri 08:00-12:00, 13:00-19:00; Sat-Sun off. Exceptions (off unless hours are given): 2007-01-01 to 2049-12-31 (Nový rok, recurring), 2007-01-01 to 2049-12-31 (Svátek práce, recurring), 2007-01-01 to 2049-12-31 (Den vítězství, recurring), 2007-01-01 to 2049-12-31 (Den slovanských věrozvěstů Cyrila a Metoděje, recurring), 2007-01-01 to 2049-12-31 (Den upálení mistra Jana Husa, recurring), 2007-01-01 to 2049-12-31 (Den české státnosti, recurring), 2007-01-01 to 2049-12-31 (Den vzniku samostatného československého státu, recurring), 2007-01-01 to 2049-12-31 (Den boje za svobodu a demokracii, recurring), 2007-01-01 to 2049-12-31 (Štědrý den, recurring), 2007-01-01 to 2049-12-31 (1. svátek vánoční, recurring), 2007-01-01 to 2049-12-31 (2. svátek vánoční, recurring), 2008-01-01 to 2008-12-31 (Velikonoční pondělí 2008, recurring).

## Resources

| Resource | Rate |
| --- | --- |
| Kolínská | 200 |
| údržbář 1 | 200 |

## Schedule

| ID | WBS | Task | Type | Duration | Start | Finish | Predecessors | Total slack | Free slack | Constraint | Deadline | Calendar | Resources | Work | Cost |
| --- | --- | --- | --- | --- | --- | --- | --- | --- | --- | --- | --- | --- | --- | --- | --- |
| 1 | Start-A | **rekonstrukce zasedací místnosti** |  | 29d | 2008-04-04 | 2008-05-16 |  | 0d |  |  |  |  |  | 120h | 24,000 |
| 2 | Start-A-1 | koncepce vybavení místnosti |  | 1w | 2008-04-04 | 2008-04-09 |  | 0d |  |  |  | Koncepce | Kolínská; údržbář 1 | 80h | 16,000 |
| 3 | Start-A-2 | rozpočet vybavení místnosti |  | 2d | 2008-04-08 | 2008-04-09 | 2SS+2d | 0d |  |  |  |  |  |  |  |
| 4 | Start-A-3 | schválení koncepce a rozpočtu vybavení |  | 1d | 2008-04-10 | 2008-04-10 | 2, 3 | 0d |  |  |  |  |  |  |  |
| 5 | Start-A-4 | výběr a objednání počítačů |  | 3d | 2008-04-11 | 2008-04-15 | 4 | 10d | 0d |  |  |  |  |  |  |
| 6 | Start-A-5 | dodání počítačů a dataprojektoru |  | 1d | 2008-04-30 | 2008-04-30 | 5FS+2w | 10d | 9d |  |  |  |  |  |  |
| 7 | Start-A-6 | zazdění dveří |  | 2d | 2008-04-11 | 2008-04-14 | 4 | 8d | 0d |  |  |  |  |  |  |
| 8 | Start-A-7 | podhled |  | 2d | 2008-04-15 | 2008-04-16 | 7 | 8d | 0d |  |  |  |  |  |  |
| 9 | Start-A-8 | elektroinstalace |  | 1d | 2008-04-17 | 2008-04-17 | 8 | 8d | 0d |  |  |  |  |  |  |
| 10 | Start-A-9 | vymalování |  | 1d | 2008-04-18 | 2008-04-18 | 9 | 8d | 9d | finish no later than 2008-04-30 |  |  |  |  |  |
| 11 | Start-A-10 | položení koberce |  | 1d | 2008-05-05 | 2008-05-05 | 10 | 0d |  | as late as possible | 2008-05-05 |  |  |  |  |
| 12 | Start-A-11 | výběr a objednání nábytku |  | 3d | 2008-04-11 | 2008-04-15 | 4 | 0d |  |  |  |  |  |  |  |
| 13 | Start-A-12 | dodání a montáž nábytku |  | 1d | 2008-05-09 | 2008-05-09 | 11, 12FS+3w | 0d |  |  |  |  |  |  |  |
| 14 | Start-A-13 | vyvětrání |  | 5ed | 2008-05-09 | 2008-05-14 | 13 | 4.88d | 1.88d |  |  |  |  |  |  |
| 15 | Start-A-14 | instalace sítě |  | 1d | 2008-05-15 | 2008-05-15 | 14 | 1d | 0d |  |  |  |  |  |  |
| 16 | Start-A-15 | instalace počítačů |  | 1d | 2008-05-16 | 2008-05-16 | 15, 6 | 1d | 0d |  |  |  |  |  |  |
| 17 | Start-A-16 | příprava rezervačního software |  | 5d | 2008-04-04 | 2008-04-15 |  | 20.38d |  |  |  |  | Kolínská | 40h | 8,000 |
| 18 | Start-A-17 | zahájení provozu místnosti | milestone | 0d | 2008-05-16 | 2008-05-16 | 17, 16 | 1d | 0d |  |  |  |  |  |  |
| 19 | Start-B | **akce uvedení nového software na trh** |  | 52d | 2008-04-11 | 2008-06-25 |  | 0d |  |  |  |  |  |  |  |
| 20 | Start-B-1 | webová prezentace uvedení |  | 2d | 2008-05-19 | 2008-05-20 | 18 | 1d |  |  |  |  |  |  |  |
| 21 | Start-B-2 | přihlašování na uvedení |  | 15ed | 2008-06-03 | 2008-06-18 | 20FS+2w | 4.88d | 0d |  |  |  |  |  |  |
| 22 | Start-B-3 | objednání občerstvení |  | 1d | 2008-04-11 | 2008-04-11 | 4 | 39d |  |  |  |  |  |  |  |
| 23 | Start-B-4 | návrh letáků k uvedení |  | 2d | 2008-04-11 | 2008-04-14 | 4 | 40d | 0d |  |  |  |  |  |  |
| 24 | Start-B-5 | dodání letáků | milestone | 0d | 2008-04-14 | 2008-04-14 | 23 | 40d | 0d |  |  |  |  |  |  |
| 25 | Start-B-6 | rozeslání pozvánek |  | 2d | 2008-04-15 | 2008-04-16 | 24 | 47d |  |  |  |  |  |  |  |
| 26 | Start-B-7 | výběr, objednání propagačních materiálů |  | 1d | 2008-04-11 | 2008-04-11 | 4 | 39d | 0d |  |  |  |  |  |  |
| 27 | Start-B-8 | dodání propagačních materiálů | milestone | 0d | 2008-04-11 | 2008-04-11 | 26 | 39d | 0d |  |  |  |  |  |  |
| 28 | Start-B-9 | milník přípravy akce uvedení | milestone | 0d | 2008-04-18 | 2008-04-18 | 27FS+5d, 24FS+3d | 39d |  |  |  |  |  |  |  |
| 29 | Start-B-10 | uzávěrka přihlašování | milestone | 0d | 2008-06-18 | 2008-06-18 | 21 | 1d |  |  |  |  |  |  |  |
| 30 | Start-B-11 | průběh akce uvedení software |  | 1d | 2008-06-24 | 2008-06-24 | 28FS+1w, 22FS+10d, 29FS+2d | 0d |  | must start on 2008-06-24 |  |  |  |  |  |
| 31 | Start-B-12 | tisková zpráva o uvedení |  | 1d | 2008-06-25 | 2008-06-25 | 30, 25 | 0d |  |  |  |  |  |  |  |

| ID | WBS | Task | Duration | Start | Finish | Total slack | Constraint | Calendar |
| --- | --- | --- | --- | --- | --- | --- | --- | --- |
| 32 | Start-C | **porada vedení** | 44d | 2008-04-11 | 2008-06-13 | 8d |  | Rodiče |
| 33 | Start-C-1 | porada vedení 1 | 1d | 2008-04-11 | 2008-04-11 | 51d | start no earlier than 2008-04-11 | Rodiče |
| 34 | Start-C-2 | porada vedení 2 | 1d | 2008-05-12 | 2008-05-12 | 32d | start no earlier than 2008-05-09 | Rodiče |
| 35 | Start-C-3 | porada vedení 3 | 1d | 2008-06-13 | 2008-06-13 | 8d | start no earlier than 2008-06-13 | Rodiče |
