# Start

Schedule from MS Project, 2008-04-07 to 2008-06-25, status date 2008-04-15, costs in Kč, A marks actual dates.
Encián

## Calendars

- Standardní 2: Mon-Fri 08:00-12:00, 13:00-17:00; Sat-Sun off. Exceptions (off unless hours are given): 2007-01-01 to 2049-12-31 (Nový rok, recurring), 2007-01-01 to 2049-12-31 (Svátek práce, recurring), 2007-01-01 to 2049-12-31 (Den vítězství, recurring), 2007-01-01 to 2049-12-31 (Den slovanských věrozvěstů Cyrila a Metoděje, recurring), 2007-01-01 to 2049-12-31 (Den upálení mistra Jana Husa, recurring), 2007-01-01 to 2049-12-31 (Den české státnosti, recurring), 2007-01-01 to 2049-12-31 (Den vzniku samostatného československého státu, recurring), 2007-01-01 to 2049-12-31 (Den boje za svobodu a demokracii, recurring), 2007-01-01 to 2049-12-31 (Štědrý den, recurring), 2007-01-01 to 2049-12-31 (1. svátek vánoční, recurring), 2007-01-01 to 2049-12-31 (2. svátek vánoční, recurring), 2008-01-01 to 2008-12-31 (Velikonoční pondělí 2008, recurring).
- Rodiče: Mon-Fri 08:00-12:00, 13:00-17:00; Sat-Sun off. Exceptions (off unless hours are given): 2007-01-01 to 2049-12-31 (Nový rok, recurring), 2007-01-01 to 2049-12-31 (Svátek práce, recurring), 2007-01-01 to 2049-12-31 (Den vítězství, recurring), 2007-01-01 to 2049-12-31 (Den slovanských věrozvěstů Cyrila a Metoděje, recurring), 2007-01-01 to 2049-12-31 (Den upálení mistra Jana Husa, recurring), 2007-01-01 to 2049-12-31 (Den české státnosti, recurring), 2007-01-01 to 2049-12-31 (Den vzniku samostatného československého státu, recurring), 2007-01-01 to 2049-12-31 (Den boje za svobodu a demokracii, recurring), 2007-01-01 to 2049-12-31 (Štědrý den, recurring), 2007-01-01 to 2049-12-31 (1. svátek vánoční, recurring), 2007-01-01 to 2049-12-31 (2. svátek vánoční, recurring), 2008-01-01 to 2008-12-31 (Velikonoční pondělí 2008, recurring), 2008-05-17 08:00-12:00, 13:00-17:00 (Pracovní sobota), 2008-05-19 (Volné pondělí).
- Koncepce: Mon-Fri 08:00-12:00, 13:00-19:00; Sat-Sun off. Exceptions (off unless hours are given): 2007-01-01 to 2049-12-31 (Nový rok, recurring), 2007-01-01 to 2049-12-31 (Svátek práce, recurring), 2007-01-01 to 2049-12-31 (Den vítězství, recurring), 2007-01-01 to 2049-12-31 (Den slovanských věrozvěstů Cyrila a Metoděje, recurring), 2007-01-01 to 2049-12-31 (Den upálení mistra Jana Husa, recurring), 2007-01-01 to 2049-12-31 (Den české státnosti, recurring), 2007-01-01 to 2049-12-31 (Den vzniku samostatného československého státu, recurring), 2007-01-01 to 2049-12-31 (Den boje za svobodu a demokracii, recurring), 2007-01-01 to 2049-12-31 (Štědrý den, recurring), 2007-01-01 to 2049-12-31 (1. svátek vánoční, recurring), 2007-01-01 to 2049-12-31 (2. svátek vánoční, recurring), 2008-01-01 to 2008-12-31 (Velikonoční pondělí 2008, recurring).

## Resources

| Resource | Group | Unit | Rate | Cost per use | Notes |
| --- | --- | --- | --- | --- | --- |
| Kolínská | PRG |  | 200 |  |  |
| údržbáři | P |  | 150 |  |  |
| Janda | ANA |  | 200 |  |  |
| Dvořák | KON |  | 200 |  |  |
| Benešová | DIS |  | 200 |  |  |
| zedníci | V |  | 150 | 500 |  |
| Sladká | RED |  | 150 |  |  |
| Smetana | REK |  | 200 |  | Milan Smetana je na dlouhodbé zahraniční služební cestě do 13. 4. 2008, po níž bude zčásti vázán na jiném projektu, proto jeho maximální počet jednotek je následující: / ·do 13. 4. 2008: 0 %, / ·od 14. 4. 2008: 50 %. |
| Novák | RED |  | 200 |  |  |
| malíři | V |  | 150 | 500 |  |
| koberec |  | m2 | 200 |  |  |
| rozeslání pozvánky |  | ks | 15 | 100 |  |
| síťový kabel |  | m. | 5 |  |  |
| papír |  |  |  |  |  |
| toner |  |  |  |  |  |
| telefon |  |  |  |  |  |
| občerstvení |  |  |  |  |  |
| interní nákladový rozpočet |  |  |  |  |  |
| externí nákladový rozpočet |  |  |  |  |  |
| pracovní rozpočet |  |  | 200 |  |  |
| rozpočet síťových kabelů |  |  |  |  |  |

## Schedule

| ID | WBS | Task | Type | Duration | Start | Finish | Predecessors | Complete | Remaining | Baseline start | Baseline finish | Baseline duration | Baseline 1 start | Baseline 1 finish | Total slack | Free slack | Constraint | Deadline | Calendar | Resources | Work | Actual work | Cost | Baseline cost | Actual cost |
| --- | --- | --- | --- | --- | --- | --- | --- | --- | --- | --- | --- | --- | --- | --- | --- | --- | --- | --- | --- | --- | --- | --- | --- | --- | --- |
| 1 | Start-A | **rekonstrukce zasedací místnosti** |  | 28d | 2008-04-07 A | 2008-05-16 |  | 44% | 15.55d | 2008-04-07 | 2008-05-16 | 28d | 2008-04-07 | 2008-05-16 | 1d |  |  |  |  | papír [0%]; toner [0%]; telefon [0%] | 182h | 110.25h | 950,065 | 950,665 | 19,400 |
| 2 | Start-A-1 | koncepce vybavení místnosti |  | 1w | 2008-04-07 A | 2008-04-10 A |  | 100% |  | 2008-04-07 | 2008-04-10 | 1w | 2008-04-07 | 2008-04-10 |  |  |  |  | Koncepce | Kolínská [50%]; údržbáři [50%] | 40h | 40h | 7,200 | 7,200 | 7,200 |
| 3 | Start-A-2 | rozpočet vybavení místnosti |  | 2d | 2008-04-09 A | 2008-04-10 A | 2SS+2d | 100% |  | 2008-04-09 | 2008-04-10 | 2d | 2008-04-09 | 2008-04-10 |  |  |  |  |  | Sladká | 16h | 16h | 2,400 | 2,400 | 2,400 |
| 4 | Start-A-3 | schválení koncepce a rozpočtu vybavení |  | 1d | 2008-04-11 A | 2008-04-11 A | 2, 3 | 100% |  | 2008-04-11 | 2008-04-11 | 1d | 2008-04-11 | 2008-04-11 |  |  |  |  |  | Novák [25%] | 2h | 2h | 400 | 400 | 400 |
| 5 | Start-A-4 | výběr a objednání počítačů |  | 3d | 2008-04-14 A | 2008-04-16 | 4 | 71% | 0.88d | 2008-04-14 | 2008-04-16 | 3d | 2008-04-14 | 2008-04-16 | 9.25d | 0d |  |  |  | Kolínská [25%] | 6h | 4.25h | 1,200 | 1,200 | 850 |
| 6 | Start-A-5 | dodání počítačů a dataprojektoru |  | 1d | 2008-04-30 | 2008-05-05 | 5FS+2w |  |  | 2008-04-30 | 2008-05-05 | 1d | 2008-04-30 | 2008-05-05 | 8.38d | 7.38d |  |  |  | Kolínská [25%] | 2h |  | 678,183 | 678,183 |  |
| 7 | Start-A-6 | zazdění dveří |  | 1d | 2008-04-14 A | 2008-04-14 A | 4 | 100% |  | 2008-04-14 | 2008-04-15 | 2d | 2008-04-14 | 2008-04-14 |  |  |  |  |  | zedníci [50%] | 4h | 4h | 850 | 1,450 | 850 |
| 8 | Start-A-7 | podhled |  | 2d | 2008-04-15 A | 2008-04-16 | 7 | 50% | 1d | 2008-04-16 | 2008-04-17 | 2d | 2008-04-15 | 2008-04-16 | 8d | 0d |  |  |  | údržbáři [200%] | 32h | 16h | 12,200 | 12,200 | 1,600 |
| 9 | Start-A-8 | elektroinstalace |  | 1d | 2008-04-17 | 2008-04-17 | 8 |  |  | 2008-04-18 | 2008-04-18 | 1d | 2008-04-17 | 2008-04-17 | 8d | 0d |  |  |  | údržbáři [200%] | 16h |  | 3,600 | 3,600 |  |
| 10 | Start-A-9 | vymalování |  | 1d | 2008-04-18 | 2008-04-18 | 9 |  |  | 2008-04-21 | 2008-04-21 | 1d | 2008-04-18 | 2008-04-18 | 8d |  | finish no later than 2008-04-30 |  |  | malíři [200%] | 16h |  | 3,400 | 3,400 |  |
| 11 | Start-A-10 | položení koberce |  | 1d | 2008-05-05 | 2008-05-05 | 10 |  |  | 2008-05-05 | 2008-05-05 | 1d | 2008-05-05 | 2008-05-05 | 0d |  | as late as possible | 2008-05-05 |  | údržbáři [50%]; koberec [92 m2] | 4h |  | 19,200 | 19,200 |  |
| 12 | Start-A-11 | výběr a objednání nábytku |  | 2d | 2008-04-14 A | 2008-04-15 A | 4 | 100% |  | 2008-04-14 | 2008-04-15 | 2d | 2008-04-14 | 2008-04-15 |  |  |  |  |  | Sladká [50%] | 12h | 12h | 2,000 | 2,000 | 2,000 |
| 13 | Start-A-12 | dodání a montáž nábytku |  | 1d | 2008-05-09 | 2008-05-09 | 11, 12FS+3w |  |  | 2008-05-09 | 2008-05-09 | 1d | 2008-05-09 | 2008-05-09 | 0d |  |  |  |  |  |  |  | 211,907 | 211,907 |  |
| 14 | Start-A-13 | vyvětrání |  | 5ed | 2008-05-09 | 2008-05-14 | 13 |  |  | 2008-05-09 | 2008-05-14 | 5ed | 2008-05-09 | 2008-05-14 | 4.88d | 1.88d |  |  |  |  |  |  |  |  |  |
| 15 | Start-A-14 | instalace sítě |  | 1d | 2008-05-15 | 2008-05-15 | 14 |  |  | 2008-05-15 | 2008-05-15 | 1d | 2008-05-15 | 2008-05-15 | 1d | 0d |  |  |  | Kolínská; síťový kabel [45 m.] | 8h |  | 1,825 | 1,825 |  |
| 16 | Start-A-15 | instalace počítačů |  | 1d | 2008-05-16 | 2008-05-16 | 15, 6 |  |  | 2008-05-16 | 2008-05-16 | 1d | 2008-05-16 | 2008-05-16 | 0d |  |  |  |  | Kolínská | 8h |  | 1,600 | 1,600 |  |
| 17 | Start-A-16 | příprava rezervačního software |  | 5d | 2008-04-07 A | 2008-04-11 A |  | 100% |  | 2008-04-07 | 2008-04-11 | 5d | 2008-04-07 | 2008-04-11 |  |  |  |  |  | Kolínská [25%]; Janda [25%] | 16h | 16h | 3,200 | 3,200 | 3,200 |
| 18 | Start-A-17 | zahájení provozu místnosti | milestone | 0d | 2008-05-16 | 2008-05-16 | 17, 16 |  |  | 2008-05-16 | 2008-05-16 | 0d | 2008-05-16 | 2008-05-16 | 1d | 0d |  |  |  |  |  |  |  |  |  |
| 19 | Start-B | **akce uvedení nového software na trh** |  | 51d | 2008-04-14 A | 2008-06-25 |  | 2% | 50.07d | 2008-04-14 | 2008-06-25 | 51d | 2008-04-14 | 2008-06-25 | 0d |  |  |  |  | papír [0%]; toner [0%]; telefon [0%] | 68h | 2h | 29,400 | 29,400 | 1,200 |
| 20 | Start-B-1 | webová prezentace uvedení |  | 2d | 2008-05-17 | 2008-05-20 | 18 |  |  | 2008-05-17 | 2008-05-20 | 2d | 2008-05-17 | 2008-05-20 | 1d |  |  |  |  | Kolínská [50%] | 8h |  | 1,600 | 1,600 |  |
| 21 | Start-B-2 | přihlašování na uvedení |  | 15ed | 2008-06-03 | 2008-06-18 | 20FS+2w |  |  | 2008-06-03 | 2008-06-18 | 15ed | 2008-06-03 | 2008-06-18 | 4.88d | 0d |  |  |  |  |  |  |  |  |  |
| 22 | Start-B-3 | objednání občerstvení |  | 1d | 2008-04-14 A | 2008-04-14 A | 4 | 100% |  | 2008-04-14 | 2008-04-14 | 1d | 2008-04-14 | 2008-04-14 |  |  |  |  |  | Sladká [25%] | 2h | 2h | 300 | 300 | 300 |
| 23 | Start-B-4 | návrh letáků k uvedení |  | 2d | 2008-04-17 | 2008-04-18 | 4 |  |  | 2008-04-17 | 2008-04-18 | 2d | 2008-04-17 | 2008-04-18 | 36d | 0d |  |  |  | Smetana [50%] | 8h |  | 1,600 | 1,600 |  |
| 24 | Start-B-5 | dodání letáků | milestone | 0d | 2008-04-18 | 2008-04-18 | 23 |  |  | 2008-04-18 | 2008-04-18 | 0d | 2008-04-18 | 2008-04-18 | 36d | 0d |  |  |  |  |  |  | 3,200 | 3,200 |  |
| 25 | Start-B-6 | rozeslání pozvánek |  | 2d | 2008-04-22 | 2008-04-23 | 24 |  |  | 2008-04-22 | 2008-04-23 | 2d | 2008-04-22 | 2008-04-23 | 42d |  |  |  |  | Sladká; rozeslání pozvánky [100 ks] | 16h |  | 4,000 | 4,000 |  |
| 26 | Start-B-7 | výběr, objednání propagačních materiálů |  | 1d | 2008-04-21 | 2008-04-21 | 4 |  |  | 2008-04-21 | 2008-04-21 | 1d | 2008-04-21 | 2008-04-21 | 33d | 0d |  |  |  | Sladká | 8h |  | 1,200 | 1,200 |  |
| 27 | Start-B-8 | dodání propagačních materiálů | milestone | 0d | 2008-04-21 | 2008-04-21 | 26 |  |  | 2008-04-21 | 2008-04-21 | 0d | 2008-04-21 | 2008-04-21 | 33d | 0d |  |  |  |  |  |  | 6,800 | 6,800 |  |
| 28 | Start-B-9 | milník přípravy akce uvedení | milestone | 0d | 2008-04-28 | 2008-04-28 | 27FS+5d, 24FS+3d |  |  | 2008-04-28 | 2008-04-28 | 0d | 2008-04-28 | 2008-04-28 | 33d |  |  |  |  |  |  |  |  |  |  |
| 29 | Start-B-10 | uzávěrka přihlašování | milestone | 0d | 2008-06-18 | 2008-06-18 | 21 |  |  | 2008-06-18 | 2008-06-18 | 0d | 2008-06-18 | 2008-06-18 | 1d |  |  |  |  |  |  |  |  |  |  |
| 30 | Start-B-11 | průběh akce uvedení software |  | 1d | 2008-06-24 | 2008-06-24 | 28FS+1w, 22FS+10d, 29FS+2d |  |  | 2008-06-24 | 2008-06-24 | 1d | 2008-06-24 | 2008-06-24 | 0d |  | must start on 2008-06-24 |  |  | Novák; Kolínská; Sladká; občerstvení [6.2%] | 24h |  | 9,400 | 9,400 |  |
| 31 | Start-B-12 | tisková zpráva o uvedení |  | 1d | 2008-06-25 | 2008-06-25 | 30, 25 |  |  | 2008-06-25 | 2008-06-25 | 1d | 2008-06-25 | 2008-06-25 | 0d |  |  |  |  | Novák [25%] | 2h |  | 400 | 400 |  |

| ID | WBS | Task | Duration | Start | Finish | Complete | Remaining | Baseline start | Baseline finish | Baseline duration | Baseline 1 start | Baseline 1 finish | Total slack | Constraint | Calendar | Resources | Work | Actual work | Cost | Baseline cost | Actual cost |
| --- | --- | --- | --- | --- | --- | --- | --- | --- | --- | --- | --- | --- | --- | --- | --- | --- | --- | --- | --- | --- | --- |
| 32 | Start-C | **porada vedení** | 44d | 2008-04-11 A | 2008-06-13 | 33% | 29.33d | 2008-04-11 | 2008-06-13 | 44d | 2008-04-11 | 2008-06-13 | 8d |  | Rodiče |  | 40h | 12h | 7,850 | 7,850 | 2,300 |
| 33 | Start-C-1 | porada vedení 1 | 1d | 2008-04-11 A | 2008-04-11 A | 100% |  | 2008-04-11 | 2008-04-11 | 1d | 2008-04-11 | 2008-04-11 |  | start no earlier than 2008-04-11 | Rodiče | občerstvení [0.1%]; Novák [25%]; Sladká [25%]; Dvořák [25%]; Benešová [25%]; Janda [25%]; Kolínská [25%] | 12h | 12h | 2,350 | 2,350 | 2,300 |
| 34 | Start-C-2 | porada vedení 2 | 1d | 2008-05-12 | 2008-05-12 |  |  | 2008-05-12 | 2008-05-12 | 1d | 2008-05-12 | 2008-05-12 | 32d | start no earlier than 2008-05-09 | Rodiče | občerstvení [0.1%]; Novák [25%]; Sladká [25%]; Dvořák [25%]; Smetana [25%]; Benešová [25%]; Janda [25%]; Kolínská [25%] | 14h |  | 2,750 | 2,750 |  |
| 35 | Start-C-3 | porada vedení 3 | 1d | 2008-06-13 | 2008-06-13 |  |  | 2008-06-13 | 2008-06-13 | 1d | 2008-06-13 | 2008-06-13 | 8d | start no earlier than 2008-06-13 | Rodiče | občerstvení [0.1%]; Novák [25%]; Sladká [25%]; Dvořák [25%]; Smetana [25%]; Benešová [25%]; Janda [25%]; Kolínská [25%] | 14h |  | 2,750 | 2,750 |  |
